# Cronograma-Theoprax

Schedule from MS Project, 2022-04-04 to 2022-12-01, costs in R$.

## Calendars

- Padrão: Mon-Fri 09:00-12:00, 13:00-18:00; Sat-Sun off.

## Resources

| Resource | Group | Unit | Rate |
| --- | --- | --- | --- |
| Computador | Equipamento | Un |  |
| Cadeira | Mobilia | Un |  |
| Felipe Cerqueira | RH |  |  |
| Gustavo Ribeiro | RH |  |  |
| João Pedro Alban | RH |  |  |
| José Ambrozi | RH |  |  |
| Marina Peixoto | RH |  |  |
| Rodrigo Eliotério | RH |  |  |
| Mesa | Mobilia | Un |  |
| Diego Wernek | RH |  |  |
| Excel | Sistemas | Un |  |
| Pyton | Sistemas | Un |  |
| Clockfy | Sistemas | Un |  |
| Lucidchart | Sistemas | Un |  |
| Power BI premium | Sistemas | Un | 128 |

## Schedule

| ID | WBS | Task | Type | Duration | Start | Finish | Predecessors | Total slack | Free slack | Resources | Work | Cost |
| --- | --- | --- | --- | --- | --- | --- | --- | --- | --- | --- | --- | --- |
| 1 | 1 | **Criação de dashboard para gestão de recursos humanos e financeira no setor da Eletrônica Embarcada do SENAI CIMATEC** |  | 173.31d | 2022-04-04 | 2022-12-01 |  | 0d |  | Power BI premium [1 Un] | 4783.76h | 128 |
| 2 | 1.1 | **Detalhamento do cenário atual e as necessidades do cliente** |  | 49.01d | 2022-04-04 | 2022-06-10 |  | 0d |  |  | 1529.36h |  |
| 3 | 1.1.1 | **Iniciação** |  | 9.11d | 2022-04-04 | 2022-04-15 |  | 0d |  | Computador [1 Un] | 510.16h |  |
| 4 | 1.1.1.1 | **Termo de confidencialidade** |  | 8.5d | 2022-04-04 | 2022-04-14 |  | 0d |  |  | 476h |  |
| 5 | 1.1.1.1.1 | Elaborar o termo |  | 5d | 2022-04-04 | 2022-04-08 |  | 0d |  | Diego Wernek; Felipe Cerqueira; Gustavo Ribeiro; João Pedro Alban; José Ambrozi; Marina Peixoto; Rodrigo Eliotério | 280h |  |
| 6 | 1.1.1.1.2 | Recolher as assinaturas de todos os envolvidos no projeto |  | 3d | 2022-04-11 | 2022-04-13 | 5 | 0d |  | Diego Wernek; Felipe Cerqueira; Gustavo Ribeiro; João Pedro Alban; José Ambrozi; Marina Peixoto; Rodrigo Eliotério | 168h |  |
| 7 | 1.1.1.1.3 | Anexar/salvar os documentos no Drive |  | 0.5d | 2022-04-14 | 2022-04-14 | 6 | 0d |  | Diego Wernek; Felipe Cerqueira; Gustavo Ribeiro; João Pedro Alban; José Ambrozi; Marina Peixoto; Rodrigo Eliotério | 28h |  |
| 8 | 1.1.1.1.4 | Início do projeto | milestone | 0d | 2022-04-04 | 2022-04-04 |  | 8.5d |  |  |  |  |
| 9 | 1.1.1.2 | **Autorização do projeto** |  | 0.61d | 2022-04-14 | 2022-04-15 | 4 | 0d |  | Diego Wernek; Felipe Cerqueira; Gustavo Ribeiro; João Pedro Alban; José Ambrozi; Marina Peixoto; Rodrigo Eliotério | 34.16h |  |
| 10 | 1.1.1.2.1 | Preencher o termo de autorização do projeto |  | 0.5d | 2022-04-14 | 2022-04-14 |  | 0d |  |  |  |  |
| 11 | 1.1.1.2.2 | Apresentar o termo de autorização para o cliente |  | 0.1d | 2022-04-15 | 2022-04-15 | 10 | 0d |  |  |  |  |
| 12 | 1.1.1.2.3 | Assinar o termo de autorização por parte do cliente |  | 0.01d | 2022-04-15 | 2022-04-15 | 11 | 0d |  |  |  |  |
| 13 | 1.1.1.2.4 | Projeto autorizado | milestone | 0d | 2022-04-15 | 2022-04-15 | 12 | 0d |  |  |  |  |
| 14 | 1.1.2 | **Planejamento** |  | 35.2d | 2022-04-15 | 2022-06-03 | 3 | 0d |  |  | 913.6h |  |
| 15 | 1.1.2.1 | **Plano de Gerenciamento do Projeto** |  | 11.5d | 2022-04-15 | 2022-05-02 |  | 0d |  | Cadeira [1 Un]; Computador [1 Un]; Mesa [1 Un] | 204.8h |  |
| 16 | 1.1.2.1.1 | Elaborar Plano de Gerenciamento de Escopo |  | 1d | 2022-04-15 | 2022-04-18 |  | 0d |  | Diego Wernek; Felipe Cerqueira; Gustavo Ribeiro; João Pedro Alban; José Ambrozi; Marina Peixoto; Rodrigo Eliotério | 56h |  |
| 17 | 1.1.2.1.2 | Elaborar EAP |  | 1.5d | 2022-04-18 | 2022-04-19 | 16 | 0d |  | Diego Wernek; Felipe Cerqueira; Gustavo Ribeiro; João Pedro Alban; José Ambrozi; Excel [1 Un]; Lucidchart [1 Un] | 60h |  |
| 18 | 1.1.2.1.3 | Elaborar Plano de Gerenciamento de Tempo |  | 1d | 2022-04-19 | 2022-04-20 | 17 | 8d |  | Diego Wernek | 8h |  |
| 19 | 1.1.2.1.4 | Elaborar Cronograma |  | 2d | 2022-04-19 | 2022-04-21 | 17 | 6.7d | 0d | João Pedro Alban; Excel [1 Un] | 16h |  |
| 20 | 1.1.2.1.5 | Elaborar Plano de Gerenciamento de Custo |  | 1d | 2022-04-19 | 2022-04-20 | 17 | 0d |  | Gustavo Ribeiro | 8h |  |
| 21 | 1.1.2.1.6 | Elaborar Orçamento |  | 0.2d | 2022-04-20 | 2022-04-20 | 20 | 0d |  | Felipe Cerqueira; Gustavo Ribeiro | 3.2h |  |
| 22 | 1.1.2.1.7 | Elaborar Plano de Gerenciamento de Pessoas |  | 0.3d | 2022-04-21 | 2022-04-21 | 19 | 6.7d |  | João Pedro Alban; José Ambrozi | 4.8h |  |
| 23 | 1.1.2.1.8 | Elaborar Matriz de Responsabilidades |  | 1d | 2022-04-20 | 2022-04-21 | 21 | 0d |  | Gustavo Ribeiro | 8h |  |
| 24 | 1.1.2.1.9 | Elaborar Plano de Gerenciamento de Comunicações e Partes Interessadas |  | 0.5d | 2022-04-21 | 2022-04-22 | 23 | 0d |  | Marina Peixoto; Rodrigo Eliotério | 8h |  |
| 25 | 1.1.2.1.10 | Elaborar Plano de Gerenciamento de Riscos |  | 0.5d | 2022-04-22 | 2022-04-22 | 24 | 0d |  | Felipe Cerqueira; João Pedro Alban | 8h |  |
| 26 | 1.1.2.1.11 | Elaborar Plano de Resposta a Riscos |  | 0.5d | 2022-04-22 | 2022-04-25 | 25 | 0d |  | Felipe Cerqueira; João Pedro Alban | 8h |  |
| 27 | 1.1.2.1.12 | Consolidar Plano de Gerenciamento de Projeto |  | 0.3d | 2022-04-25 | 2022-04-25 | 26 | 0d |  | Diego Wernek; Felipe Cerqueira; Gustavo Ribeiro; João Pedro Alban; José Ambrozi; Marina Peixoto; Rodrigo Eliotério | 16.8h |  |
| 28 | 1.1.2.1.13 | Buffer |  | 5d | 2022-04-25 | 2022-05-02 | 27 | 0d |  |  |  |  |
| 29 | 1.1.2.1.14 | Plano de Projeto concluído | milestone | 0d | 2022-05-02 | 2022-05-02 | 28 | 0d |  |  |  |  |

| ID | WBS | Task | Type | Duration | Start | Finish | Predecessors | Total slack | Free slack | Resources | Work |
| --- | --- | --- | --- | --- | --- | --- | --- | --- | --- | --- | --- |
| 30 | 1.1.2.2 | **Apresentação do plano do projeto** |  | 4.2d | 2022-05-02 | 2022-05-06 | 15 | 0d |  | Cadeira [1 Un]; Computador [1 Un]; Mesa [1 Un]; Excel [1 Un] | 159.2h |
| 31 | 1.1.2.2.1 | Realizar uma apresentação explicando a metodologia do Theoprax |  | 2d | 2022-05-02 | 2022-05-04 |  | 0d |  | Diego Wernek; Felipe Cerqueira; Gustavo Ribeiro; João Pedro Alban; José Ambrozi; Marina Peixoto | 96h |
| 32 | 1.1.2.2.2 | Realizar uma apresentação da necessidade do projeto no setor |  | 1.5d | 2022-05-04 | 2022-05-06 | 31 | 0d |  | Felipe Cerqueira; Marina Peixoto | 24h |
| 33 | 1.1.2.2.3 | Realizar uma apresentação das limitações e riscos que a equipe enfrentarar, na execução do projeto |  | 0.7d | 2022-05-06 | 2022-05-06 | 32 | 0d |  | Diego Wernek; Felipe Cerqueira; Gustavo Ribeiro; João Pedro Alban; José Ambrozi; Marina Peixoto; Rodrigo Eliotério | 39.2h |
| 34 | 1.1.2.3 | **Reunião com os líderes** |  | 3.5d | 2022-05-06 | 2022-05-12 | 30 | 0d |  | Cadeira [1 Un]; Computador [1 Un]; Mesa [1 Un] | 109.6h |
| 35 | 1.1.2.3.1 | Marcar uma reunião de apresentação do projeto |  | 1d | 2022-05-06 | 2022-05-09 |  | 0d |  | José Ambrozi | 8h |
| 36 | 1.1.2.3.2 | Identificar as necessidades |  | 1.2d | 2022-05-09 | 2022-05-11 | 35 | 0d |  | Felipe Cerqueira; José Ambrozi; Marina Peixoto | 28.8h |
| 37 | 1.1.2.3.3 | Identificar as nossas limitações |  | 1.3d | 2022-05-11 | 2022-05-12 | 36 | 0d |  | Diego Wernek; Felipe Cerqueira; Gustavo Ribeiro; João Pedro Alban; José Ambrozi; Marina Peixoto; Rodrigo Eliotério | 72.8h |
| 38 | 1.1.2.4 | **Análise bruta dos dados e do cenário atual do setor** |  | 16d | 2022-05-12 | 2022-06-03 | 34 | 0d |  | Cadeira [1 Un]; Computador [1 Un]; Excel [1 Un]; Mesa [1 Un] | 440h |
| 39 | 1.1.2.4.1 | Analisar os bancos de dados |  | 8d | 2022-05-12 | 2022-05-24 |  | 0d |  | Felipe Cerqueira; José Ambrozi; Marina Peixoto | 192h |
| 40 | 1.1.2.4.2 | Identificar a origem das fontes de dados |  | 5d | 2022-05-24 | 2022-05-31 | 39 | 0d |  | Felipe Cerqueira; Marina Peixoto | 80h |
| 41 | 1.1.2.4.3 | Reunir a equipe para análise e discussão dos dados |  | 3d | 2022-05-31 | 2022-06-03 | 40 | 0d |  | Diego Wernek; Felipe Cerqueira; Gustavo Ribeiro; João Pedro Alban; José Ambrozi; Marina Peixoto; Rodrigo Eliotério | 168h |
| 42 | 1.1.3 | **Controle** |  | 4.7d | 2022-06-03 | 2022-06-10 | 14 | 0d |  | Computador [1 Un]; Excel [1 Un]; Cadeira [1 Un]; Mesa [1 Un] | 105.6h |
| 43 | 1.1.3.1 | **Reuniões** |  | 2.5d | 2022-06-03 | 2022-06-07 |  | 2.2d |  |  | 20h |
| 44 | 1.1.3.1.1 | Definir periodicidade para realização das reuniões |  | 0.5d | 2022-06-03 | 2022-06-03 |  | 2.2d | 0d | Rodrigo Eliotério | 4h |
| 45 | 1.1.3.1.2 | Alinhar com o cliente |  | 1d | 2022-06-03 | 2022-06-06 | 44 | 2.2d | 0d | Felipe Cerqueira | 8h |
| 46 | 1.1.3.1.3 | Agendar as datas no Google Calendário |  | 1d | 2022-06-06 | 2022-06-07 | 45 | 2.2d |  | João Pedro Alban | 8h |
| 47 | 1.1.3.2 | **Ata de reunião** |  | 1.7d | 2022-06-03 | 2022-06-07 |  | 0d |  |  | 13.6h |
| 48 | 1.1.3.2.1 | Elaborar um modelo de ata |  | 0.5d | 2022-06-03 | 2022-06-03 |  | 0d |  | Gustavo Ribeiro | 4h |
| 49 | 1.1.3.2.2 | Definir os responsável para elaboração das atas de cada reunião |  | 1d | 2022-06-03 | 2022-06-06 | 48 | 0d |  | Gustavo Ribeiro | 8h |
| 50 | 1.1.3.2.3 | Enviar para assinatura dos presentes em cada reunião |  | 0.2d | 2022-06-06 | 2022-06-07 | 49 | 0d |  | Gustavo Ribeiro | 1.6h |
| 51 | 1.1.3.3 | **Visitas técnicas ao setor** |  | 3d | 2022-06-07 | 2022-06-10 | 47 | 0d |  |  | 72h |
| 52 | 1.1.3.3.1 | Definir as datas de visitas |  | 1d | 2022-06-07 | 2022-06-08 |  | 0d |  | Diego Wernek | 8h |
| 53 | 1.1.3.3.2 | Alinhar com o cliente |  | 1d | 2022-06-08 | 2022-06-09 | 52 | 0d |  | Felipe Cerqueira | 8h |
| 54 | 1.1.3.3.3 | Definir os membros que estarão presentes em cada reunião |  | 1d | 2022-06-09 | 2022-06-10 | 53 | 0d |  | Diego Wernek; Felipe Cerqueira; Gustavo Ribeiro; João Pedro Alban; José Ambrozi; Marina Peixoto; Rodrigo Eliotério | 56h |
| 55 | 1.1.4 | Fase inicial concluída | milestone | 0d | 2022-06-10 | 2022-06-10 | 51 | 124.3d |  |  |  |

| ID | WBS | Task | Duration | Start | Finish | Predecessors | Total slack | Resources | Work |
| --- | --- | --- | --- | --- | --- | --- | --- | --- | --- |
| 56 | 1.2 | **Construção das premissas para construção do Dashboard** | 61.8d | 2022-06-10 | 2022-09-05 | 42 | 0d |  | 1750.4h |
| 57 | 1.2.1 | **Estudo geral** | 23.5d | 2022-06-10 | 2022-07-13 |  | 0d | Cadeira [1 Un]; Computador [1 Un]; Mesa [1 Un] | 752h |
| 58 | 1.2.1.1 | **Análise de viabilidade** | 5.5d | 2022-06-10 | 2022-06-17 |  | 0d |  | 128h |
| 59 | 1.2.1.1.1 | Identificar as limitações da plataforma (Power BI) | 3.5d | 2022-06-10 | 2022-06-15 |  | 0d | Felipe Cerqueira; José Ambrozi; Marina Peixoto | 84h |
| 60 | 1.2.1.1.2 | Definir os responsaves pela elaboração do Dashboard | 0.5d | 2022-06-15 | 2022-06-16 | 59 | 0d | Diego Wernek; Gustavo Ribeiro; João Pedro Alban; José Ambrozi; Rodrigo Eliotério | 20h |
| 61 | 1.2.1.1.3 | Definir a base técnica para a elaboração do Dashboard | 1.5d | 2022-06-16 | 2022-06-17 | 60 | 0d | Felipe Cerqueira; Marina Peixoto | 24h |
| 62 | 1.2.1.2 | **Levantamento das fontes de dados gerais** | 10d | 2022-06-17 | 2022-07-01 | 58 | 0d |  | 360h |
| 63 | 1.2.1.2.1 | Verificar se as fontes de dados são compatíveis com o Power BI | 3d | 2022-06-17 | 2022-06-22 |  | 0d | Felipe Cerqueira; Marina Peixoto; Pyton [1 Un] | 48h |
| 64 | 1.2.1.2.2 | Definir um fluxo de dados para a comunicação com o Power BI | 2d | 2022-06-22 | 2022-06-24 | 63 | 0d | Felipe Cerqueira; Marina Peixoto | 32h |
| 65 | 1.2.1.2.3 | Criar uma tabela centralizadora dos dados | 5d | 2022-06-24 | 2022-07-01 | 64 | 0d | Diego Wernek; Felipe Cerqueira; Gustavo Ribeiro; João Pedro Alban; José Ambrozi; Marina Peixoto; Rodrigo Eliotério | 280h |
| 66 | 1.2.1.3 | **Levantamento das fontes de dados do financeiro** | 8d | 2022-07-01 | 2022-07-13 | 62 | 0d |  | 264h |
| 67 | 1.2.1.3.1 | Identificar a origem dos dados | 1d | 2022-07-01 | 2022-07-04 |  | 0d | Felipe Cerqueira; Marina Peixoto | 16h |
| 68 | 1.2.1.3.2 | Verificar se as fontes de dados são compatíveis com o Power BI | 1.2d | 2022-07-04 | 2022-07-05 | 67 | 0d | Felipe Cerqueira; José Ambrozi; Excel [1 Un] | 19.2h |
| 69 | 1.2.1.3.3 | Definir um fluxo de dados para a comunicação com o Power BI | 1.8d | 2022-07-05 | 2022-07-07 | 68 | 0d | Diego Wernek; Felipe Cerqueira; Gustavo Ribeiro; João Pedro Alban; José Ambrozi; Marina Peixoto; Rodrigo Eliotério | 100.8h |
| 70 | 1.2.1.3.4 | Criar uma tabela centralizadora dos dados | 4d | 2022-07-07 | 2022-07-13 | 69 | 0d | Diego Wernek; Felipe Cerqueira; João Pedro Alban; José Ambrozi | 128h |
| 71 | 1.2.2 | **Levantamento de dados** | 16.5d | 2022-07-13 | 2022-08-05 | 57 | 0d | Cadeira [1 Un]; Computador [1 Un]; Mesa [1 Un] | 369.6h |
| 72 | 1.2.2.1 | **Descrição dos bancos de dados** | 3d | 2022-07-13 | 2022-07-18 |  | 0d |  | 72h |
| 73 | 1.2.2.1.1 | Identificar o modelo dos bancos de dados | 1d | 2022-07-13 | 2022-07-14 |  | 0d | Felipe Cerqueira; José Ambrozi; Marina Peixoto; Rodrigo Eliotério | 32h |
| 74 | 1.2.2.1.2 | Identificar o responsável pela atualização dos dados | 1d | 2022-07-14 | 2022-07-15 | 73 | 0d | Felipe Cerqueira | 8h |
| 75 | 1.2.2.1.3 | Fazer a atualização dos dados | 1d | 2022-07-15 | 2022-07-18 | 74 | 0d | Felipe Cerqueira; José Ambrozi; Marina Peixoto; Diego Wernek | 32h |
| 76 | 1.2.2.2 | **Verificação do formato de cada banco** | 3d | 2022-07-18 | 2022-07-21 | 72 | 0d |  | 72.8h |
| 77 | 1.2.2.2.1 | Identificar o formato de cada banco | 0.8d | 2022-07-18 | 2022-07-19 |  | 0d | Felipe Cerqueira; Marina Peixoto | 12.8h |
| 78 | 1.2.2.2.2 | Fazer uma planilha com as verificações do formato de cada banco | 1.3d | 2022-07-19 | 2022-07-20 | 77 | 0d | Gustavo Ribeiro; João Pedro Alban; José Ambrozi | 31.2h |
| 79 | 1.2.2.2.3 | Adequar os formatos, se necessário | 0.9d | 2022-07-20 | 2022-07-21 | 78 | 0d | Diego Wernek; Felipe Cerqueira; Marina Peixoto; Rodrigo Eliotério | 28.8h |

| ID | WBS | Task | Type | Duration | Start | Finish | Predecessors | Total slack | Resources | Work |
| --- | --- | --- | --- | --- | --- | --- | --- | --- | --- | --- |
| 80 | 1.2.2.3 | **Verificação do local de armazenamento** |  | 4d | 2022-07-21 | 2022-07-27 | 76 | 0d |  | 76.8h |
| 81 | 1.2.2.3.1 | Mapear onde estão armazenados esses bancos de dados |  | 1.4d | 2022-07-21 | 2022-07-22 |  | 0d | Felipe Cerqueira; José Ambrozi | 22.4h |
| 82 | 1.2.2.3.2 | Definir locais para armazenamento dos recortes (views) fornecidos dos bancos de dados |  | 1.6d | 2022-07-22 | 2022-07-26 | 81 | 0d | Diego Wernek; Felipe Cerqueira; Marina Peixoto | 38.4h |
| 83 | 1.2.2.3.3 | Alinhar com o cliente |  | 0.4d | 2022-07-26 | 2022-07-26 | 82 | 0d | Felipe Cerqueira; José Ambrozi | 6.4h |
| 84 | 1.2.2.3.4 | Reunir com a equipe do TI |  | 0.6d | 2022-07-26 | 2022-07-27 | 83 | 0d | Felipe Cerqueira; Marina Peixoto | 9.6h |
| 85 | 1.2.2.4 | **Identificação do responsável pela alimentação dos bancos de dados** |  | 3d | 2022-07-27 | 2022-08-01 | 80 | 0d |  | 48h |
| 86 | 1.2.2.4.1 | Mapear quem alimenta cada banco de dados |  | 1.5d | 2022-07-27 | 2022-07-29 |  | 0d | Felipe Cerqueira | 12h |
| 87 | 1.2.2.4.2 | Realizar reuniões com a equipe responsavel pela alimentação dos bancos de dados |  | 0.8d | 2022-07-29 | 2022-07-29 | 86 | 0d | Felipe Cerqueira; José Ambrozi; Marina Peixoto | 19.2h |
| 88 | 1.2.2.4.3 | Identificar a periodicidade das atualizações |  | 0.7d | 2022-07-29 | 2022-08-01 | 87 | 0d | Felipe Cerqueira; José Ambrozi; Marina Peixoto | 16.8h |
| 89 | 1.2.2.5 | **Levantamento dos principais dados gerados por cada banco** |  | 3.5d | 2022-08-01 | 2022-08-05 | 85 | 0d |  | 100h |
| 90 | 1.2.2.5.1 | Identificar quais dados são fornecidos por cada banco |  | 2d | 2022-08-01 | 2022-08-03 |  | 0d | Felipe Cerqueira; José Ambrozi; Marina Peixoto | 48h |
| 91 | 1.2.2.5.2 | Identificar quais informações tais dados podem gerar |  | 1d | 2022-08-03 | 2022-08-04 | 90 | 0d | Felipe Cerqueira; José Ambrozi; Marina Peixoto | 24h |
| 92 | 1.2.2.5.3 | Alinhar com o cliente as principais informações devem ser tratadas e analisadas |  | 0.5d | 2022-08-04 | 2022-08-05 | 91 | 0d | Diego Wernek; Felipe Cerqueira; Gustavo Ribeiro; João Pedro Alban; José Ambrozi; Marina Peixoto; Rodrigo Eliotério | 28h |
| 93 | 1.2.3 | **Levantamento técnico** |  | 21.8d | 2022-08-05 | 2022-09-05 | 71 | 0d | Cadeira [1 Un]; Clockfy [1 Un]; Mesa [1 Un] | 628.8h |
| 94 | 1.2.3.1 | **Identificação dos indicadores mais pertinentes para tomadas de decisões** |  | 1.3d | 2022-08-05 | 2022-08-08 |  | 0d |  | 40.8h |
| 95 | 1.2.3.1.1 | Definir, junto ao cliente, quais informações são relevantes nas tomadas de decisões do setor |  | 0.1d | 2022-08-05 | 2022-08-05 |  | 0d | Diego Wernek; Felipe Cerqueira; Gustavo Ribeiro; João Pedro Alban; José Ambrozi; Marina Peixoto; Rodrigo Eliotério | 5.6h |
| 96 | 1.2.3.1.2 | Definir, junto ao cliente, quais indicadores gerarão tais informações |  | 0.2d | 2022-08-05 | 2022-08-05 | 95 | 0d | Diego Wernek; Felipe Cerqueira; Gustavo Ribeiro; João Pedro Alban; José Ambrozi; Marina Peixoto; Rodrigo Eliotério | 11.2h |
| 97 | 1.2.3.1.3 | Estudar como esse indicador será mostrado (c/ gráficos, tabelas...) |  | 1d | 2022-08-05 | 2022-08-08 | 96 | 0d | Gustavo Ribeiro; José Ambrozi; Rodrigo Eliotério | 24h |
| 98 | 1.2.3.2 | **Estruturação dos dados para gerar as informações desejadas** |  | 9.5d | 2022-08-08 | 2022-08-19 | 94 | 0d |  | 316h |
| 99 | 1.2.3.2.1 | Estudar quais relações precisam ser criadas nos bancos de dados para gerar as informações desejadas |  | 2d | 2022-08-08 | 2022-08-10 |  | 0d | Excel [1 Un]; Gustavo Ribeiro; João Pedro Alban; José Ambrozi; Rodrigo Eliotério | 64h |
| 100 | 1.2.3.2.2 | Ver compatibilidade dos bancos de dados |  | 3d | 2022-08-10 | 2022-08-15 | 99 | 0d | Gustavo Ribeiro; José Ambrozi; Marina Peixoto | 72h |
| 101 | 1.2.3.2.3 | Estruturar no Power BI |  | 4.5d | 2022-08-15 | 2022-08-19 | 100 | 0d | Felipe Cerqueira; Gustavo Ribeiro; João Pedro Alban; José Ambrozi; Rodrigo Eliotério | 180h |
| 102 | 1.2.3.3 | **Organização da validação dos dados** |  | 11d | 2022-08-19 | 2022-09-05 | 98 | 0d |  | 272h |
| 103 | 1.2.3.3.1 | Identificar vulnerabilidades da atual tabela centratalizada |  | 3d | 2022-08-19 | 2022-08-24 |  | 0d | Felipe Cerqueira; Marina Peixoto | 48h |
| 104 | 1.2.3.3.2 | Reestrutar atual tabela centralizadora para validação de dados |  | 4d | 2022-08-24 | 2022-08-30 | 103 | 0d | Gustavo Ribeiro; João Pedro Alban; José Ambrozi; Rodrigo Eliotério | 128h |
| 105 | 1.2.3.3.3 | Organizar validação de dados |  | 4d | 2022-08-30 | 2022-09-05 | 104 | 0d | Felipe Cerqueira; Gustavo Ribeiro; João Pedro Alban | 96h |
| 106 | 1.2.3.3.4 | Fase de estudos e levantamento de dados concluída | milestone | 0d | 2022-09-05 | 2022-09-05 | 105 | 0d |  |  |

| ID | WBS | Task | Type | Duration | Start | Finish | Predecessors | Total slack | Resources | Work |
| --- | --- | --- | --- | --- | --- | --- | --- | --- | --- | --- |
| 107 | 1.3 | **Execução do projeto e testes de validação** |  | 62.5d | 2022-09-05 | 2022-12-01 | 56 | 0d |  | 1504h |
| 108 | 1.3.1 | **Automatização da atualização de dados** |  | 23d | 2022-09-05 | 2022-10-06 |  | 0d | Cadeira [1 Un]; Computador [1 Un]; Mesa [1 Un]; Pyton [1 Un] | 568h |
| 109 | 1.3.1.1 | Estudar meios de automatizar a atualização de dados |  | 15d | 2022-09-05 | 2022-09-26 |  | 0d | Diego Wernek; Felipe Cerqueira; Marina Peixoto | 360h |
| 110 | 1.3.1.2 | Realizar testes das automatizações das atualizações de dados |  | 5d | 2022-09-26 | 2022-10-03 | 109 | 0d | Gustavo Ribeiro; João Pedro Alban; José Ambrozi; Rodrigo Eliotério | 160h |
| 111 | 1.3.1.3 | Eliminar os erros gerados na fase de testes |  | 3d | 2022-10-03 | 2022-10-06 | 110 | 0d | José Ambrozi; Rodrigo Eliotério | 48h |
| 112 | 1.3.1.4 | Atualização de dados automatizada | milestone | 0d | 2022-10-06 | 2022-10-06 | 111 | 0d |  |  |
| 113 | 1.3.2 | **Integração do Clockify** |  | 8d | 2022-10-06 | 2022-10-18 | 108 | 0d | Cadeira [1 Un]; Clockfy [1 Un]; Computador [1 Un]; Excel [1 Un]; Mesa [1 Un]; Pyton [1 Un] | 128h |
| 114 | 1.3.2.1 | Reestruturar o Clockify |  | 3d | 2022-10-06 | 2022-10-11 |  | 0d | Felipe Cerqueira; Marina Peixoto | 48h |
| 115 | 1.3.2.2 | Atualizar as informações no clockify |  | 4d | 2022-10-11 | 2022-10-17 | 114 | 0d | Felipe Cerqueira; Marina Peixoto; Clockfy [1 Un]; Pyton [1 Un] | 64h |
| 116 | 1.3.2.3 | Realizar testes de uso da plataforma |  | 1d | 2022-10-17 | 2022-10-18 | 115 | 0d | Felipe Cerqueira; Marina Peixoto; Clockfy [1 Un]; Pyton [1 Un] | 16h |
| 117 | 1.3.3 | **Testes de atualização de dados** |  | 8d | 2022-10-18 | 2022-10-28 | 113 | 0d | Clockfy [1 Un]; Excel [1 Un]; Cadeira [1 Un]; Computador [1 Un]; Mesa [1 Un] | 192h |
| 118 | 1.3.3.1 | Testar o funcionamento da atualização de dados |  | 4d | 2022-10-18 | 2022-10-24 |  | 0d | Diego Wernek; Felipe Cerqueira; Marina Peixoto | 96h |
| 119 | 1.3.3.2 | Validar os erros indentificados ou pontos de melhoria |  | 3d | 2022-10-24 | 2022-10-27 | 118 | 0d | Diego Wernek; Felipe Cerqueira; José Ambrozi | 72h |
| 120 | 1.3.3.3 | Testar novamente com as melhorias aplicadas |  | 1d | 2022-10-27 | 2022-10-28 | 119 | 0d | Diego Wernek; Felipe Cerqueira; José Ambrozi | 24h |
| 121 | 1.3.4 | **Verificação do Clockify** |  | 5d | 2022-10-28 | 2022-11-04 | 117 | 0d | Clockfy [1 Un]; Mesa [1 Un]; Cadeira [1 Un]; Computador [1 Un] | 96h |
| 122 | 1.3.4.1 | Verificar como o pessoal utiliza o Clockify |  | 2d | 2022-10-28 | 2022-11-01 |  | 0d | José Ambrozi; Marina Peixoto | 32h |
| 123 | 1.3.4.2 | Identificar frequência com que o pessoal utiliza o Clockify |  | 1d | 2022-11-01 | 2022-11-02 | 122 | 0d | José Ambrozi; Marina Peixoto | 16h |
| 124 | 1.3.4.3 | Identificar erros ou problemas no cadastramento do pessoal ou das áreas |  | 2d | 2022-11-02 | 2022-11-04 | 123 | 0d | Diego Wernek; Felipe Cerqueira; Marina Peixoto | 48h |
| 125 | 1.3.5 | **Validação dos dashboards criados e integrações feitas** |  | 7.5d | 2022-11-04 | 2022-11-16 | 121 | 0d | Cadeira [1 Un]; Computador [1 Un]; Excel [1 Un]; Mesa [1 Un]; Pyton [1 Un] | 192h |
| 126 | 1.3.5.1 | Checar se dashboards mostram as informações corretas |  | 3d | 2022-11-04 | 2022-11-09 |  | 0d | Felipe Cerqueira; Gustavo Ribeiro; João Pedro Alban; José Ambrozi; Rodrigo Eliotério | 120h |
| 127 | 1.3.5.2 | Identificar vulnerabilidades |  | 2d | 2022-11-09 | 2022-11-11 | 126 | 0d | Gustavo Ribeiro; Rodrigo Eliotério | 32h |
| 128 | 1.3.5.3 | Corrigir erros |  | 2.5d | 2022-11-11 | 2022-11-16 | 127 | 0d | Rodrigo Eliotério; Gustavo Ribeiro | 40h |
| 129 | 1.3.5.4 | Dashboard concluído e testado | milestone | 0d | 2022-11-16 | 2022-11-16 | 128 | 0d |  |  |
| 130 | 1.3.6 | **Criação do Manual de Utilização e Manutenção das planilhas, dashboards e clockify** |  | 11d | 2022-11-16 | 2022-12-01 | 125 | 0d | Cadeira [1 Un]; Computador [1 Un]; Mesa [1 Un] | 328h |
| 131 | 1.3.6.1 | Definir sumário do manual |  | 1d | 2022-11-16 | 2022-11-17 |  | 0d | Gustavo Ribeiro; João Pedro Alban; José Ambrozi | 24h |
| 132 | 1.3.6.2 | Ordenar os itens por relevância ou criar uma estratégia que facilite a leitura |  | 2d | 2022-11-17 | 2022-11-21 | 131 | 0d | Diego Wernek; Gustavo Ribeiro; Rodrigo Eliotério | 48h |
| 133 | 1.3.6.3 | Elaborar manual |  | 7d | 2022-11-21 | 2022-11-30 | 132 | 0d | Gustavo Ribeiro; João Pedro Alban; José Ambrozi; Rodrigo Eliotério | 224h |
| 134 | 1.3.6.4 | Definir local em que ele será armazenado e disponibilizado |  | 1d | 2022-11-30 | 2022-12-01 | 133 | 0d | Gustavo Ribeiro; João Pedro Alban; José Ambrozi; Rodrigo Eliotério | 32h |
| 135 | 1.3.6.5 | Projeto concluído | milestone | 0d | 2022-12-01 | 2022-12-01 | 134 | 0d |  |  |
